# UmbauBootshausKRA_V2

Schedule from MS Project, 2013-12-06 to 2017-03-24, A marks actual dates.
KIT

## Calendars

- Standard: Mon-Fri 08:00-12:00, 13:00-17:00; Sat-Sun off.

## Schedule

| ID | WBS | Task | Type | Duration | Start | Finish | Predecessors | Complete | Remaining | Total slack | Free slack | Constraint |
| --- | --- | --- | --- | --- | --- | --- | --- | --- | --- | --- | --- | --- |
| 1 | 1 | **Mitgliederversammlungen, Vorbereitungen, Regatten KRA** |  | 861d | 2013-12-06 A | 2017-03-24 |  | 5% | 821.86d | 0d |  |  |
| 2 | 1.1 | Jahreshauptversammlung 2013 - Beauftragung Architektenleistungen | milestone, manual | 1d | 2013-12-06 A | 2013-12-06 A |  | 100% |  |  |  |  |
| 3 | 1.2 | Pläne Umbau von O. Weis erhalten | milestone, manual | 0d | 2014-02-03 A | 2014-02-03 A | 2 | 100% |  |  |  |  |
| 4 | 1.3 | Jahreshauptversammlung 2014 - Neue Satzung mit Änderung Beschaffungen | milestone, manual | 1d | 2014-11-21 A | 2014-11-21 A |  | 100% |  |  |  |  |
| 5 | 1.4 | Jahreshauptversammlung 2015 - Primäres Ziel Umbau Bootshaus | milestone, manual | 1d | 2015-03-20 A | 2015-03-20 A |  | 100% |  |  |  |  |
| 6 | 1.5 | Jahreshauptversammlung 2016 | milestone, manual | 1d | 2016-03-11 | 2016-03-11 |  |  |  |  |  |  |
| 7 | 1.6 | Herbstregatta 2016 beim KRA | milestone, manual | 1d | 2016-10-29 | 2016-10-29 |  |  |  |  |  |  |
| 8 | 1.7 | Jahreshauptversammlung 2017 | milestone, manual | 1d | 2017-03-24 | 2017-03-24 |  |  |  |  |  |  |
| 9 | 1.8 | **Vorbereitung der Ausserordentlichen Mitgliederversammlung** |  | 79d | 2015-07-06 A | 2015-10-22 |  |  | 79d | 371d |  |  |
| 10 | 1.8.1 | Öffentliche Beiratssitzung Umbau | milestone, manual | 0d | 2015-07-06 A | 2015-07-06 A |  | 100% |  |  |  |  |
| 11 | 1.8.2 | Finanzplanung Sparkasse Vor-Ort Termin | milestone, manual | 0d | 2015-08-05 A | 2015-08-05 A |  | 100% |  |  |  |  |
| 12 | 1.8.3 | Terminfestlegung aoMV auf Vorstandssitzung | milestone, manual | 0d | 2015-09-01 | 2015-09-01 |  |  |  |  |  |  |
| 13 | 1.8.4 | Ankündigung der aoMV | milestone | 0d | 2015-09-04 | 2015-09-04 | 12FS+4d |  |  | 11d | 0d |  |
| 14 | 1.8.5 | Einladung der Mitglieder aoMV | milestone | 0d | 2015-10-09 | 2015-10-09 | 13FS+4w |  |  | 371d | 0d | start no earlier than 2015-10-09 |
| 15 | 1.8.6 | Vorbereitung aoMV |  | 10d | 2015-10-09 | 2015-10-22 | 14 |  |  | 371d |  |  |
| 16 | 1.9 | **außerordentliche Mitgliederversammlung** |  | 50d | 2015-10-23 | 2015-12-31 |  |  |  | 7d |  |  |
| 17 | 1.9.1 | Termin aoMV | milestone | 0d | 2015-10-23 | 2015-10-23 | 13FS+6w |  |  | 7d | 0d | start no earlier than 2015-10-23 |
| 18 | 1.9.2 | Erstellung des Protokolls |  | 6w | 2015-10-23 | 2015-12-03 | 17 |  |  | 97d | 0d |  |
| 19 | 1.9.3 | Einspruchsfrist Protokoll |  | 4w | 2015-12-04 | 2015-12-31 | 18 |  |  | 97d | 0d |  |
| 20 | 1.9.4 | Protokoll genehmigt | milestone | 0d | 2015-12-31 | 2015-12-31 | 19 |  |  | 97d | 0d |  |
| 21 | 2 | **Umbau Bootshaus KRA** |  | 612d | 2014-11-11 A | 2017-03-15 |  | 14% | 525.71d | 7d |  |  |
| 22 | 2.1 | **Verlängerung Erbpachtvertrag** |  | 180d | 2015-04-23 A | 2015-12-30 |  | 60% | 72d | 158d |  |  |
| 23 | 2.1.1 | Antrag stellen | milestone, manual | 0d | 2015-04-23 | 2015-04-23 |  |  |  |  |  |  |
| 24 | 2.1.2 | Antrag bearbeiten |  | 9mo | 2015-04-23 A | 2015-12-30 | 23 | 60% | 3.6mo | 158d | 0d |  |
| 25 | 2.1.3 | Antrag genehmigt | milestone | 0d | 2015-12-30 | 2015-12-30 | 24 |  |  | 158d | 0d |  |

Notes:
- 2: Beauftragung O. Weis am 13.10.13, hier Darstellung der Haushaltspositionen
- 4: Beschluß Änderung der Satzung
- 5: Wahl des Vorstands für 2 Jahre bis 2017 / Darstellung der allg. Planungen Bootshausumbau und des Haushalts für Planungsarbeiten (4000€)
- 6: Beschluß fassen zur Erhöhung des Mitgliedsbeitrags um 25%
- 8: Wahl des neuen Vorstands
- 22: Liegenschaftsamt Karlsruhe
- 23: Anruf Frau Hengst, 10.9.15 / Problem mit Vertrag, da Gebäude auf Gewerbegebiet. Änderung erforderlich.

| ID | WBS | Task | Type | Duration | Start | Finish | Predecessors | Total slack | Free slack |
| --- | --- | --- | --- | --- | --- | --- | --- | --- | --- |
| 26 | 2.2 | **Bauplanung** |  | 82d | 2015-09-04 | 2015-12-29 |  | 188d |  |
| 27 | 2.2.1 | **Vorplanung, Entwurfsplanung und Genehmigungsplanung** |  | 82d | 2015-09-04 | 2015-12-29 |  | 188d |  |
| 28 | 2.2.1.1 | Angebot anfordern Bauplanung | milestone | 0d | 2015-09-04 | 2015-09-04 | 12FS+4d | 188d | 18d |
| 29 | 2.2.1.2 | Beauftragung Bauplanung | milestone | 0d | 2015-11-03 | 2015-11-03 | 28FS+1mo, 17FS+8d | 166d | 0d |
| 30 | 2.2.1.3 | Planung, Vorbereitung der Ausschreibung und Baugenehmigung |  | 2mo | 2015-11-04 | 2015-12-29 | 29 | 166d | 0d |
| 31 | 2.2.1.4 | Standfestigkeitsberechnungen und Statik |  | 2mo | 2015-11-04 | 2015-12-29 | 29 | 323d |  |
| 32 | 2.3 | **Zuschussanträge** |  | 344d | 2015-11-20 | 2017-03-15 |  | 7d |  |
| 33 | 2.3.1 | **Antrag Zuschuß Stadt Karlsruhe** |  | 184d | 2015-11-20 | 2016-08-03 |  | 79d |  |
| 34 | 2.3.1.1 | Antrag stellen |  | 24d | 2015-11-20 | 2015-12-23 | 17FS+1mo | 167d | 0d |
| 35 | 2.3.1.2 | Bearbeitung Antrag |  | 4mo | 2015-12-24 | 2016-04-13 | 34 | 167d | 0d |
| 36 | 2.3.1.3 | Sitzung Bauausschuss der Stadt | milestone, manual | 0d | 2016-03-10 | 2016-03-10 |  |  |  |
| 37 | 2.3.1.4 | Genehmigung des Antrags | milestone | 0d | 2016-04-13 | 2016-04-13 | 35, 36 | 167d | 0d |
| 38 | 2.3.1.5 | Anweisung des Zuschusses | milestone | 0d | 2016-08-03 | 2016-08-03 | 37FS+4mo | 167d |  |
| 39 | 2.3.2 | **Antrag Zuschuß Badischer Sportbund** |  | 344d | 2015-11-20 | 2017-03-15 |  | 7d |  |
| 40 | 2.3.2.1 | Antrag stellen |  | 24d | 2015-11-20 | 2015-12-23 | 17FS+4w | 7d | 0d |
| 41 | 2.3.2.2 | Bearbeitung Antrag |  | 4mo | 2015-12-24 | 2016-04-13 | 40 | 7d | 0d |
| 42 | 2.3.2.3 | Genehmigung des Antrags | milestone | 0d | 2016-04-13 | 2016-04-13 | 41 | 7d | 0d |
| 43 | 2.3.2.4 | Zuweisung des Zuschusses | milestone | 0d | 2017-03-15 | 2017-03-15 | 42FS+12mo | 7d |  |
| 44 | 2.4 | **Finanzplan Sparkasse** |  | 124d | 2015-12-31 | 2016-06-21 |  | 158d |  |
| 45 | 2.4.1 | Antrag stellen |  | 24d | 2015-12-31 | 2016-02-02 | 25, 17FS+5w | 158d | 0d |
| 46 | 2.4.2 | Bearbeitung Antrag |  | 3mo | 2016-02-03 | 2016-04-26 | 45 | 158d | 0d |
| 47 | 2.4.3 | Genehmigung des Antrags; Finanzierung steht | milestone | 0d | 2016-04-26 | 2016-04-26 | 46 | 158d | 0d |
| 48 | 2.4.4 | Anweisung des KFW Darlehens | milestone | 0d | 2016-06-21 | 2016-06-21 | 47FS+2mo | 198d |  |
| 49 | 2.4.5 | Anweisung des Übergangsdarlehens Zwischenfinanzierung | milestone | 0d | 2016-06-21 | 2016-06-21 | 47FS+2mo | 198d |  |

Notes:
- 35: Dauer hängt von externer Einrichtung ab!
- 36: Telefonnotiz Frau Hinken, 11.9.15 / Bauausschuss tagt im Oktober15 und März16 (10.03.16) / Für die Sitzung im Oktober sind bereits alle EIngaben zusammen gestellt. / Für die Sitzung im März müssen Unterlagen im Januar16 vorliegen.
- 41: Dauer hängt von externer Einrichtung ab!
- 46: Dauer hängt von externer Einrichtung ab!
- 48: Finanzierung eines Darlehens über 100.000€. Laufzeit 10 Jahre
- 49: 250.000€ Darlehen zur Zwischenfinanzierung bis zur Anweisung der Zuschüsse Stadt Karlsruhe und BSB

| ID | WBS | Task | Type | Duration | Start | Finish | Predecessors | Complete | Remaining | Total slack | Free slack |
| --- | --- | --- | --- | --- | --- | --- | --- | --- | --- | --- | --- |
| 50 | 2.5 | **Baugenehmigung** |  | 442d | 2014-11-11 A | 2016-07-20 |  |  | 442d | 97d |  |
| 51 | 2.5.1 | Vorgespräch mit Herrn Framke, Bauordnungsamt | milestone, manual | 0d | 2014-11-11 A | 2014-11-11 A |  | 100% |  |  |  |
| 52 | 2.5.2 | Antrag stellen |  | 24d | 2016-01-29 | 2016-03-02 | 20FS+4w |  |  | 97d | 0d |
| 53 | 2.5.3 | Bearbeitung Antrag |  | 5mo | 2016-03-03 | 2016-07-20 | 52 |  |  | 97d | 0d |
| 54 | 2.5.4 | Genehmigung des Antrags | milestone | 0d | 2016-07-20 | 2016-07-20 | 53 |  |  | 97d | 0d |
| 55 | 2.6 | **Bauträger festlegen** |  | 139d | 2016-01-08 | 2016-07-20 |  |  |  | 97d |  |
| 56 | 2.6.1 | Ausschreibung |  | 2w | 2016-01-08 | 2016-01-21 | 30FS+7d |  |  | 166d | 0d |
| 57 | 2.6.2 | Erstellung Angebot |  | 2mo | 2016-01-22 | 2016-03-17 | 56 |  |  | 166d | 0d |
| 58 | 2.6.3 | Angebote auswerten |  | 4w | 2016-03-18 | 2016-04-14 | 57 |  |  | 166d | 69d |
| 59 | 2.6.4 | Auftrag erteilen | milestone | 0d | 2016-07-20 | 2016-07-20 | 54, 47, 42, 37, 58, 20 |  |  | 97d | 0d |
| 60 | 2.7 | **Baudurchführung** |  | 20d | 2016-10-12 | 2016-11-09 |  |  |  | 97d |  |
| 61 | 2.7.1 | Baubeginn | milestone | 0d | 2016-10-12 | 2016-10-12 | 59FS+3mo |  |  | 97d | 0d |
| 62 | 2.7.2 | Durchführung |  | 1mo | 2016-10-13 | 2016-11-09 | 61 |  |  | 97d | 0d |
| 63 | 2.7.3 | Richtfest | milestone | 0d | 2016-11-09 | 2016-11-09 | 62 |  |  | 97d |  |

Notes:
- 51: Gespräch mit Michael Schwan und Dietmar Kup / Inhalt behindertengerechte Ausgestaltung
- 53: Dauer hängt von externer Einrichtung ab!
